# ZProduktblad2

Schedule from MS Project, 2008-03-03 to 2008-04-01, costs in kr.

## Calendars

- Standard: Mon-Fri 08:00-12:00, 13:00-17:00; Sat-Sun off.

## Resources

| Resource | Rate | Cost per use |
| --- | --- | --- |
| Kalle | 300 |  |
| Lotta | 400 |  |
| Petter | 100 | 500 |

## Schedule

| ID | WBS | Task | Type | Duration | Start | Finish | Predecessors | Total slack | Free slack | Constraint | Deadline | Resources | Work | Cost |
| --- | --- | --- | --- | --- | --- | --- | --- | --- | --- | --- | --- | --- | --- | --- |
| 1 | 1 | **Projektmöte** |  | 15d | 2008-03-07 07:30 | 2008-03-28 08:00 |  | 2d |  |  |  |  | 6h | 3,600 |
| 2 | 1.1 | Projektmöte 1 |  | 0.5eh | 2008-03-07 07:30 | 2008-03-07 08:00 |  | 75d |  | start no earlier than 2008-03-07 07:30 |  | Kalle; Lotta; Petter | 1.5h | 900 |
| 3 | 1.2 | Projektmöte 2 |  | 0.5eh | 2008-03-14 07:30 | 2008-03-14 08:00 |  | 54d |  | start no earlier than 2008-03-14 07:30 |  | Kalle; Lotta; Petter | 1.5h | 900 |
| 4 | 1.3 | Projektmöte 3 |  | 0.5eh | 2008-03-21 07:30 | 2008-03-21 08:00 |  | 33d |  | start no earlier than 2008-03-21 07:30 |  | Kalle; Lotta; Petter | 1.5h | 900 |
| 5 | 1.4 | Projektmöte 4 |  | 0.5eh | 2008-03-28 07:30 | 2008-03-28 08:00 |  | 12d |  | start no earlier than 2008-03-28 07:30 |  | Kalle; Lotta; Petter | 1.5h | 900 |
| 6 | 2 | **Text** |  | 7.12d | 2008-03-03 08:00 | 2008-03-12 09:00 |  | -0.38d | 0d |  |  |  | 59.9h | 19,435 |
| 7 | 2.1 | Läs produktspecifikation |  | 1.25d | 2008-03-03 08:00 | 2008-03-04 10:00 |  | -0.38d | 0d |  |  | Kalle [81.2%]; Lotta [81.2%] | 13h | 4,550 |
| 8 | 2.2 | Första utkastet till text |  | 2.62d | 2008-03-03 14:00 | 2008-03-06 14:00 | 7FS-5% | -0.12d | 0d |  |  | Lotta [83.3%] | 17.5h | 7,000 |
| 9 | 2.3 | Teknisk granskning |  | 1.5d | 2008-03-06 14:00 | 2008-03-10 09:00 | 8 | -0.12d | 0d |  |  | Petter [125%] | 15h | 2,125 |
| 10 | 2.4 | Slutligt utkast |  | 2d | 2008-03-10 09:00 | 2008-03-12 09:00 | 9 | -0.12d | 0d |  | 2008-03-12 17:00 | Lotta [90%] | 14.4h | 5,760 |
| 11 | 3 | **Skapa bilder** |  | 2d | 2008-03-10 09:00 | 2008-03-12 09:00 |  | -0.12d | 0d |  |  |  | 11.2h | 1,470 |
| 12 | 3.1 | Bilder |  | 2d | 2008-03-10 09:00 | 2008-03-12 09:00 | 10SS | -0.12d | 0d |  |  | Petter [70%] | 11.2h | 1,470 |
| 13 | 4 | **Skapa layout** |  | 3d | 2008-03-12 09:00 | 2008-03-17 09:00 |  | -0.12d | 0d |  |  |  | 18h | 7,200 |
| 14 | 4.1 | Layout |  | 3d | 2008-03-12 09:00 | 2008-03-17 09:00 | 10, 12 | -0.12d | 0d | start no earlier than 2008-03-10 08:00 |  | Lotta [75%] | 18h | 7,200 |
| 15 | 5 | Tryckning av produktblad |  | 1w | 2008-03-18 09:00 | 2008-03-25 09:00 | 14FS+1d | -0.12d | 0d |  |  |  |  | 10,000 |
| 16 | 6 | Leverans | milestone | 0d | 2008-04-01 08:00 | 2008-04-01 08:00 | 15FS+1w | -0.12d | 0d | must start on 2008-04-01 08:00 |  |  |  |  |

Notes:
- 12: Bilderna hämtades från Bildbyrån utan problem.
